# Ultra fast X-ray imaging of proceses ...

Schedule from MS Project, 2010-10-11 to 2011-08-01, A marks actual dates.

## Calendars

- Standard: Mon-Fri 08:00-12:00, 13:00-17:00; Sat-Sun off.

## Resources

| Resource |
| --- |
| Stevanovic |
| Caselle |
| Stripf |
| Balzer |
| Herth |
| Vogelgesang |
| Matthias, Uros, Michelle, Vogelgesang |
| Michelle, Vogelgesang |
| Uros |
| Michelle |
| Tomy, Vladimir |
| Vladimir |
| Tomy |
| Uros, Helmut |
| Michele, Vogelgesang |
| Michele |
| Uros, Matthias |
| Suren |
| Michele, Suren |
| Armin, Uros, Michele |
| Michele, Matthias V. |
| Michele, Matthias V. X-Y |
| Michele, Matthias V. Z Movement |
| Armin |
| Uros, Michele Suren, |
| Uros, Michele, Suren |
| Suren, Vogelgesang |
| Suren, Michele |
| Michele, Matthias V. X-Y Movement |
| Armin, Michele |
| Uros, (Michele) |

## Schedule

| ID | WBS | Task | Type | Duration | Start | Finish | Predecessors | Complete | Remaining | Total slack | Free slack | Constraint | Deadline | Resources | Work |
| --- | --- | --- | --- | --- | --- | --- | --- | --- | --- | --- | --- | --- | --- | --- | --- |
| 1 | 1 | **WP4: Development of online process control** |  | 211d | 2010-10-11 A | 2011-08-01 |  | 2% | 205.85d | 0d |  |  |  |  | 10471.2h |
| 2 | 1.1 | **Task 4.1: Online fast data reject** |  | 160d | 2010-12-06 A | 2011-07-15 |  | 11% | 142.22d | 11d |  | start no earlier than 2010-09-01 |  |  | 1120h |
| 3 | 1.1.1 | Selection of sample experiment |  | 1mo | 2010-12-06 A | 2010-12-31 A |  | 100% |  |  |  | finish no earlier than 2010-12-31 |  |  |  |
| 4 | 1.1.2 | Analysis of image characteristics |  | 3mo | 2011-03-28 | 2011-06-17 | 3FS-10d, 13 |  |  | 11d | 0d | start no earlier than 2011-03-01 |  | Uros, Helmut | 480h |
| 5 | 1.1.3 | Development fast reject algorithm for FPGA implementation |  | 4mo | 2011-03-28 | 2011-07-15 | 4SS |  |  | 11d | 0d | finish no earlier than 2011-06-30 |  | Uros, (Michele) | 640h |
| 6 | 1.1.4 | Evaluation fast reject | milestone | 1mo | 2011-04-25 | 2011-05-20 | 5SS+1mo |  |  | 47d |  |  |  |  |  |
| 7 | 1.2 | **IPE Camera** |  | 129d | 2011-01-11 | 2011-07-08 |  |  |  | -129d | 0d | start no earlier than 2011-01-11 | 2011-01-10 | Stevanovic; Caselle; Stripf [10%]; Balzer [50%]; Herth [50%]; Vogelgesang | 7271.2h |
| 8 | 1.2.1 | **Communication to SCMOS CHIP** |  | 49d | 2011-01-11 | 2011-03-18 |  |  |  | -64d | 0d |  |  |  | 512h |
| 9 | 1.2.1.1 | SPI Interface |  | 39d | 2011-01-11 | 2011-03-04 |  |  |  | -54d | 0d |  |  | Uros | 312h |
| 10 | 1.2.1.2 | Scmos Detector Chip readout |  | 20d | 2011-02-21 | 2011-03-18 |  |  |  | -69d | 0d | finish no earlier than 2011-03-18 |  | Michele | 160h |
| 11 | 1.2.1.3 | Temperature Readout |  | 5d | 2011-02-28 | 2011-03-04 |  |  |  | -54d | 0d | finish no earlier than 2011-03-04 |  | Uros | 40h |
| 12 | 1.2.2 | SDRAM Interface |  | 1mo | 2011-03-21 | 2011-04-15 | 10 |  |  | -69d | 0d | start no earlier than 2011-03-18 |  | Uros, Matthias | 160h |
| 13 | 1.2.3 | DVI/VGA Interface |  | 15d | 2011-03-07 | 2011-03-25 | 9, 11 |  |  | -54d | 0d |  |  | Uros | 120h |
| 14 | 1.2.4 | **PCIe Interface** |  | 120d | 2011-01-24 | 2011-07-08 |  |  |  | -129d | 0d |  |  |  | 1440h |
| 15 | 1.2.4.1 | Definition of Functionality |  | 1mo | 2011-01-24 | 2011-02-18 |  |  |  | -129d | 0d | start no earlier than 2011-01-24 |  | Suren, Michele | 160h |
| 16 | 1.2.4.2 | FPGA Implemenatation |  | 2mo | 2011-02-21 | 2011-04-15 | 15 |  |  | -129d | 0d |  |  | Michele | 320h |
| 17 | 1.2.4.3 | SW Driver |  | 2mo | 2011-02-21 | 2011-04-15 | 15 |  |  | -129d | 0d |  |  | Suren | 320h |
| 18 | 1.2.4.4 | Test and Optimization |  | 4mo | 2011-03-21 | 2011-07-08 | 16SS+1mo, 17SS+1mo |  |  | -129d | 0d |  |  | Michele, Suren | 640h |
| 19 | 1.2.5 | Temperature Control Regulation |  | 2mo | 2011-02-18 | 2011-04-14 |  |  |  | -68d | 0d | start no earlier than 2011-02-18 |  | Armin, Michele | 320h |
| 20 | 1.2.6 | FPGA Main Control Unit 1 |  | 1mo | 2011-02-22 | 2011-03-21 |  |  |  | -50d | 0d | start no earlier than 2011-02-22 |  | Michele | 160h |
| 21 | 1.2.7 | Camera Mechanics |  | 1mo | 2011-02-18 | 2011-03-17 |  |  |  | -48d | 0d | start no earlier than 2011-02-18 |  | Armin | 160h |
| 22 | 1.2.8 | First Commisioning |  | 7d | 2011-03-15 | 2011-03-23 |  |  |  | -52d | 0d | start no earlier than 2011-03-15 | 2011-03-15 | Uros, Michele, Suren | 56h |
| 23 | 1.2.9 | Exception and Error Handling |  | 14d | 2011-05-17 | 2011-06-03 |  |  |  | -104d | 0d | start no earlier than 2011-05-17 |  | Michele, Suren | 112h |
| 25 | 1.3 | **Task 4.2: Development of control algorithms and feedback loops** |  | 211d | 2010-10-11 | 2011-08-01 |  |  |  | 0d |  |  |  |  | 2080h |
| 26 | 1.3.1 | Selection of demonstrator application |  | 3mo | 2010-10-11 | 2010-12-31 |  |  |  | 102d | 5d | finish no earlier than 2010-12-31 |  | Tomy, Vladimir | 480h |
| 27 | 1.3.2 | Development of minmal control functions |  | 2.25mo | 2011-01-03 | 2011-03-04 | 26 |  |  | 81d | 16d | finish no earlier than 2011-02-04 |  | Vladimir | 360h |
| 28 | 1.3.3 | Tango-Server Interface |  | 5d | 2011-02-25 | 2011-03-03 |  |  |  | 52d | 0d | start no earlier than 2011-02-25 |  | Vladimir | 40h |
| 29 | 1.3.4 | Specification for motion control |  | 10d | 2011-03-04 | 2011-03-17 | 28 |  |  | 52d | 6d |  |  | Vladimir | 80h |
| 30 | 1.3.5 | Oven for Test setup |  | 15d | 2011-03-01 | 2011-03-21 |  |  |  | -14d | 0d | start no earlier than 2011-03-01 | 2011-03-01 | Tomy | 120h |
| 31 | 1.3.6 | Evaluation of control loops |  | 2mo | 2011-03-28 | 2011-05-20 | 26, 27, 28, 29 |  |  | 46d | 1d | start no earlier than 2011-03-28 |  | Tomy, Vladimir | 320h |
| 32 | 1.3.7 | Test on beamline | milestone | 5d | 2011-05-24 | 2011-05-30 | 31 |  |  | 45d |  | start no earlier than 2011-05-24 |  | Tomy, Vladimir | 40h |
| 34 | 1.3.8 | Auto Focus |  | 2mo | 2011-03-29 | 2011-05-23 |  |  |  | 50d |  | start no earlier than 2011-03-29 |  | Michele, Matthias V. Z Movement | 320h |
| 35 | 1.3.9 | Camera Allignment |  | 2mo | 2011-06-07 | 2011-08-01 |  |  |  | 0d |  | start no earlier than 2011-06-07 |  | Michele, Matthias V. X-Y Movement | 320h |

Notes:
- 18: Goal: more than 700 MB/s Read from PC
- 20: PCie Data flow Scmos and diredct to PCIe at low speed or direct memory location access
- 31: Shut down Phase at ANKA
